# Harmonogram - přesunutý

Schedule from MS Project, 2014-08-22 to 2016-06-09, costs in Kč.

## Calendars

- Standardní: Mon-Fri 09:00-13:00, 14:00-18:00; Sat-Sun off.

## Resources

| Resource | Group |
| --- | --- |
| Milan Červený s.r.o. | SUB |
| Zakládání staveb,a.s. | SUB |
| FA: JANPE s.r.o. | SUB |
| IZOSTAV, s. r. o. | SUB |
| NELOstaV,s.r.o. | SUB |
| NELAN, spol. s r.o. | SUB |
| STANO PRAHA a.s. | SUB |
| ELEKTROMONTÁŽE s.r.o. | SUB |
| SORKE,spol. s r.o. | SUB |
| DOMOVNÍ VÝTAHY s.r.o. | SUB |
| PREFA PRAHA a.s. | SUB |
| Zedník | Vlastní |
| Betonář | Vlastní |
| Železář | Vlastní |
| Tesař | Vlastní |
| Stavební dělník | Vlastní |
| Omítkář | Vlastní |
| Malba | SUB |
| INPROS PRAHA, a.s. | SUB |

## Schedule

| ID | WBS | Task | Duration | Start | Finish | Predecessors | Total slack | Free slack | Constraint | Resources | Work | Cost |
| --- | --- | --- | --- | --- | --- | --- | --- | --- | --- | --- | --- | --- |
| 1 | 1 | NUS | 469d | 2014-08-22 | 2016-06-08 |  | 0.11d |  |  |  |  | 7,602,923.52 |
| 2 | 2 | **Stavba** | 469.11d? | 2014-08-22 | 2016-06-09 |  | 0d |  |  |  | 77364.6h | 108,613,188.13 |
| 3 | 2.1 | **SO01 - Obytný soubor Na Vackově - budova A** | 459.14d? | 2014-09-04 | 2016-06-09 |  | 0d |  |  |  | 74886.4h | 106,007,578.71 |
| 4 | 2.1.1 | **HSV** | 276.24d? | 2014-09-04 | 2015-09-28 |  | 0d |  |  |  | 43161.9h | 48,413,846.7 |
| 5 | 2.1.1.1 | Přesun hmot HSV | 211.66d? | 2014-11-13 | 2015-09-04 | 6 | 0d |  |  | Stavební dělník [200%] | 3386.51h | 2,742,246.69 |
| 6 | 2.1.1.2 | Zemní práce | 21.1d | 2014-09-04 | 2014-10-06 | 155, 152 | 0d |  |  | Milan Červený s.r.o. [1200%] | 2025.21h | 2,728,684.01 |
| 7 | 2.1.1.3 | **Základy** | 56.11d? | 2014-10-06 | 2014-12-23 |  | 0d |  |  |  | 8027.2h | 11,363,896.65 |
| 8 | 2.1.1.3.1 | Piloty | 18.64d | 2014-10-06 | 2014-10-30 | 6 | 0d |  |  | Zakládání staveb,a.s. [1000%] | 1490.99h | 2,196,125.46 |
| 9 | 2.1.1.3.2 | Izolace základů - vodorovné | 2.38d? | 2014-11-10 | 2014-11-13 | 8FS+7d | 0d |  |  | Stavební dělník [3000%] | 572.15h | 765,661.5 |
| 10 | 2.1.1.3.3 | **Základ - bílá vana** | 24.51d? | 2014-11-13 | 2014-12-17 |  | 0d |  |  |  | 5391.91h | 7,636,448.19 |
| 11 | 2.1.1.3.3.1 | Základ - podkladí beton | 1.92d? | 2014-11-13 | 2014-11-17 | 9 | 0d |  |  | Betonář [1200%]; Stavební dělník [1000%]; Železář [800%]; Tesař [800%] | 409.66h | 833,788.83 |
| 12 | 2.1.1.3.3.2 | Základ - Bílá vana - bednění | 4.62d | 2014-11-17 | 2014-11-21 | 11 | 0d |  |  | Zakládání staveb,a.s. [1500%] | 554.03h | 403,713.81 |
| 13 | 2.1.1.3.3.3 | Základ - Bílá vana - výztuž | 11.7d | 2014-11-21 | 2014-12-09 | 12 | 0d |  |  | Zakládání staveb,a.s. [4000%] | 3745.17h | 4,313,474.42 |
| 14 | 2.1.1.3.3.4 | Základ - Bílá vana - beton | 3.07d | 2014-12-09 | 2014-12-12 | 13 | 0d |  |  | Zakládání staveb,a.s. [2000%] | 490.79h | 1,976,181.14 |
| 15 | 2.1.1.3.3.5 | Základ - Bílá vana - odbednění | 1.2d | 2014-12-16 | 2014-12-17 | 14FS+2d | 0d |  |  | Zakládání staveb,a.s. [2000%] | 192.26h | 109,289.99 |
| 16 | 2.1.1.3.4 | Izolace základů - svislé | 3.58d | 2014-12-17 | 2014-12-23 | 15 | 179.31d | 0d |  | IZOSTAV, s. r. o. [2000%] | 572.15h | 765,661.5 |
| 17 | 2.1.1.4 | Obsyp | 8.87d | 2014-12-23 | 2015-01-05 | 16, 153, 148, 149, 150, 151 | 179.31d | 174.44d |  | FA: JANPE s.r.o. [4000%] | 2839.92h | 759,752.18 |
| 18 | 2.1.1.5 | **Hrubá stavba** | 200.61d? | 2014-12-17 | 2015-09-24 |  | 0d |  |  |  | 24036.6h | 27,749,097.02 |
| 19 | 2.1.1.5.1 | **1PP** | 42.64d? | 2014-12-17 | 2015-02-16 |  | 0d |  |  |  | 2085.75h | 2,534,580.59 |
| 20 | 2.1.1.5.1.1 | Sloupy - bednění | 0.32d? | 2014-12-17 | 2014-12-17 | 15 | 0d |  |  | Tesař [1000%]; Stavební dělník [2800%] | 98.76h | 151,256.3 |
| 21 | 2.1.1.5.1.2 | Sloupy - výztuž | 0.49d? | 2014-12-17 | 2014-12-18 | 20 | 0d |  |  | Železář [1500%]; Stavební dělník [2800%] | 169.62h | 165,058.08 |
| 22 | 2.1.1.5.1.3 | Sloupy - beton | 0.22d? | 2014-12-18 | 2014-12-18 | 21 | 0d |  |  | Stavební dělník [500%]; Betonář [2000%] | 44.29h | 57,055.14 |
| 23 | 2.1.1.5.1.4 | Sloupy - odbednění | 0.12d? | 2014-12-29 | 2014-12-29 | 22FS+7d | 0d |  |  | Tesař [1000%]; Stavební dělník [2800%] | 35.3h | 19,818.68 |
| 24 | 2.1.1.5.1.5 | Prefabrikovaná výtahová šachta - 1PP | 1.2d? | 2014-12-17 | 2014-12-18 | 15 | 159.63d | 33.67d |  | PREFA PRAHA a.s. [200%] | 19.15h | 124,946.77 |
| 25 | 2.1.1.5.1.6 | Stropy - zřízení podpěr - 1PP | 0.54d? | 2014-12-29 | 2014-12-30 | 23 | 0d |  |  | Tesař [1000%]; Stavební dělník [2800%] | 162.71h | 142,803.15 |
| 26 | 2.1.1.5.1.7 | Stropy - bednění - 1PP | 1.56d? | 2014-12-30 | 2014-12-31 | 25 | 0d |  |  | Tesař [1000%]; Stavební dělník [2000%] | 375.55h | 272,669.32 |
| 27 | 2.1.1.5.1.8 | Stropy - výztuž - 1PP | 2.24d? | 2014-12-31 | 2015-01-05 | 26 | 0d |  |  | Železář [1500%]; Stavební dělník [2000%] | 626.29h | 762,010.68 |
| 28 | 2.1.1.5.1.9 | Stropy - beton - 1PP | 0.81d? | 2015-01-05 | 2015-01-05 | 27 | 0d |  |  | Betonář [2500%]; Stavební dělník [1500%] | 260.69h | 630,781.84 |
| 29 | 2.1.1.5.1.10 | Stropy - odbednění - 1PP | 1.46d? | 2015-02-03 | 2015-02-04 | 28FS+14d | 125.96d | 0d | start no earlier than 2015-02-03 | Stavební dělník [2800%]; Tesař [1000%] | 194.58h | 74,322.09 |
| 30 | 2.1.1.5.1.11 | Stropy - odstranění podpěr - 1PP | 1.33d? | 2015-02-12 | 2015-02-16 | 28FS+28d | 131.27d | 30.02d |  | Stavební dělník [800%] | 85.33h | 35,112 |
| 31 | 2.1.1.5.1.12 | Prefabrikové schodiště a balkóny - 1PP | 0.84d? | 2015-02-04 | 2015-02-05 | 29 | 147.81d | 24.57d |  | PREFA PRAHA a.s. [200%] | 13.48h | 98,746.54 |

| ID | WBS | Task | Duration | Start | Finish | Predecessors | Total slack | Free slack | Constraint | Resources | Work | Cost |
| --- | --- | --- | --- | --- | --- | --- | --- | --- | --- | --- | --- | --- |
| 32 | 2.1.1.5.2 | **1NP** | 52.02d? | 2015-01-19 | 2015-04-01 |  | 0d |  |  |  | 4054.08h | 4,288,262.41 |
| 33 | 2.1.1.5.2.1 | Zdivo nosné - bednění - 1NP | 4.37d? | 2015-01-19 | 2015-01-26 | 28FS+10d | 0d |  |  | Tesař [1000%]; Stavební dělník [2000%] | 1048.22h | 725,340.17 |
| 34 | 2.1.1.5.2.2 | Zdivo nosné - výztuž - 1NP | 2.51d? | 2015-01-26 | 2015-01-28 | 33 | 0d |  |  | Železář [1500%]; Stavební dělník [2000%] | 703.31h | 712,599.03 |
| 35 | 2.1.1.5.2.3 | Zdivo nosné - beton - 1NP | 0.87d? | 2015-01-28 | 2015-01-29 | 34 | 0d |  |  | Betonář [2500%]; Stavební dělník [500%] | 208.1h | 508,989.49 |
| 36 | 2.1.1.5.2.4 | Zdivo nosné - odbednění - 1NP | 1.17d? | 2015-02-09 | 2015-02-10 | 35FS+7d | 0d |  |  | Tesař [1000%]; Stavební dělník [2800%] | 356.67h | 199,941.33 |
| 37 | 2.1.1.5.2.5 | Prefabrikovaná výtahová šachta - 1NP | 1.2d? | 2015-02-04 | 2015-02-05 | 29, 24 | 125.96d | 24.22d |  | PREFA PRAHA a.s. [200%] | 19.15h | 124,946.77 |
| 38 | 2.1.1.5.2.6 | Stropy - zřízení podpěr - 1NP | 0.54d? | 2015-02-10 | 2015-02-11 | 36 | 0d |  |  | Tesař [1000%]; Stavební dělník [2800%] | 162.71h | 142,803.15 |
| 39 | 2.1.1.5.2.7 | Stropy - bednění - 1NP | 1.56d? | 2015-02-11 | 2015-02-12 | 38 | 0d |  |  | Tesař [1000%]; Stavební dělník [2000%] | 375.55h | 272,669.32 |
| 40 | 2.1.1.5.2.8 | Stropy - výztuž - 1NP | 2.61d? | 2015-02-12 | 2015-02-17 | 39 | 0d |  |  | Železář [1500%]; Stavební dělník [1500%] | 626.29h | 762,010.68 |
| 41 | 2.1.1.5.2.9 | Stropy - beton - 1NP | 0.72d? | 2015-02-17 | 2015-02-18 | 40 | 0d |  |  | Betonář [2500%]; Stavební dělník [2000%] | 260.69h | 630,781.84 |
| 42 | 2.1.1.5.2.10 | Stropy - odbednění - 1NP | 1.62d? | 2015-03-10 | 2015-03-11 | 41FS+14d | 101.74d | 0d |  | Tesař [1000%]; Stavební dělník [500%] | 194.58h | 74,322.09 |
| 43 | 2.1.1.5.2.11 | Stropy - odstranění podpěr - 1NP | 2.67d? | 2015-03-30 | 2015-04-01 | 41FS+28d, 30 | 112.98d | 28.71d |  | Stavební dělník [400%] | 85.33h | 35,112 |
| 44 | 2.1.1.5.2.12 | Prefabrikové schodiště a balkóny - 1NP | 0.84d? | 2015-03-11 | 2015-03-12 | 42, 31 | 123.24d | 33.09d |  | PREFA PRAHA a.s. [200%] | 13.48h | 98,746.54 |
| 45 | 2.1.1.5.3 | **2NP** | 54.71d? | 2015-03-04 | 2015-05-19 |  | 0d |  |  |  | 4054.04h | 4,288,262.41 |
| 46 | 2.1.1.5.3.1 | Zdivo nosné - bednění - 2NP | 3.74d? | 2015-03-04 | 2015-03-09 | 41FS+10d | 0d |  |  | Tesař [1000%]; Stavební dělník [2500%] | 1048.2h | 725,340.17 |
| 47 | 2.1.1.5.3.2 | Zdivo nosné - výztuž - 2NP | 2.51d? | 2015-03-09 | 2015-03-12 | 46 | 0d |  |  | Železář [1500%]; Stavební dělník [2000%] | 703.31h | 712,599.03 |
| 48 | 2.1.1.5.3.3 | Zdivo nosné - beton - 2NP | 0.87d? | 2015-03-12 | 2015-03-13 | 47 | 0d |  |  | Betonář [2500%]; Stavební dělník [500%] | 208.1h | 508,989.49 |
| 49 | 2.1.1.5.3.4 | Zdivo nosné - odbednění - 2NP | 1.78d? | 2015-03-24 | 2015-03-26 | 48FS+7d | 0d |  |  | Tesař [1000%]; Stavební dělník [1500%] | 356.66h | 199,941.33 |
| 50 | 2.1.1.5.3.5 | Prefabrikovaná výtahová šachta - 2NP | 1.2d? | 2015-03-11 | 2015-03-13 | 42, 37 | 101.74d | 32.74d |  | PREFA PRAHA a.s. [200%] | 19.15h | 124,946.77 |
| 51 | 2.1.1.5.3.6 | Stropy - zřízení podpěr - 2NP | 0.68d? | 2015-03-26 | 2015-03-26 | 49 | 0d |  |  | Tesař [1000%]; Stavební dělník [2000%] | 162.71h | 142,803.15 |
| 52 | 2.1.1.5.3.7 | Stropy - bednění - 2NP | 1.56d? | 2015-03-26 | 2015-03-30 | 51 | 0d |  |  | Tesař [1000%]; Stavební dělník [2000%] | 375.55h | 272,669.32 |
| 53 | 2.1.1.5.3.8 | Stropy - výztuž - 2NP | 2.61d? | 2015-03-30 | 2015-04-02 | 52 | 0d |  |  | Železář [1500%]; Stavební dělník [1500%] | 626.29h | 762,010.68 |
| 54 | 2.1.1.5.3.9 | Stropy - beton - 2NP | 0.61d? | 2015-04-02 | 2015-04-02 | 53 | 0d |  |  | Betonář [2500%]; Stavební dělník [2800%] | 260.69h | 630,781.84 |
| 55 | 2.1.1.5.3.10 | Stropy - odbednění - 2NP | 0.81d? | 2015-04-28 | 2015-04-28 | 54FS+14d | 69.01d | 0d | start no earlier than 2015-04-28 | Tesař [1000%]; Stavební dělník [2000%] | 194.57h | 74,322.09 |
| 56 | 2.1.1.5.3.11 | Stropy - odstranění podpěr - 2NP | 5.33d? | 2015-05-12 | 2015-05-19 | 54FS+28d, 43 | 84.27d | 24.26d |  | Stavební dělník [200%] | 85.33h | 35,112 |
| 57 | 2.1.1.5.3.12 | Prefabrikové schodiště a balkóny - 2NP | 0.84d? | 2015-04-28 | 2015-04-29 | 55, 44 | 90.14d | 30.08d |  | PREFA PRAHA a.s. [200%] | 13.48h | 98,746.54 |

| ID | WBS | Task | Duration | Start | Finish | Predecessors | Total slack | Free slack | Constraint | Resources | Work | Cost |
| --- | --- | --- | --- | --- | --- | --- | --- | --- | --- | --- | --- | --- |
| 58 | 2.1.1.5.4 | **3NP** | 52.71d? | 2015-04-16 | 2015-06-30 |  | 0d |  |  |  | 4054.05h | 4,288,262.41 |
| 59 | 2.1.1.5.4.1 | Zdivo nosné - bednění - 3NP | 3.45d? | 2015-04-16 | 2015-04-22 | 54FS+10d | 0d |  |  | Tesař [1000%]; Stavební dělník [2800%] | 1048.2h | 725,340.17 |
| 60 | 2.1.1.5.4.2 | Zdivo nosné - výztuž - 3NP | 2.04d? | 2015-04-22 | 2015-04-24 | 59 | 0d |  |  | Železář [1500%]; Stavební dělník [2800%] | 703.32h | 712,599.03 |
| 61 | 2.1.1.5.4.3 | Zdivo nosné - beton - 3NP | 0.87d? | 2015-04-24 | 2015-04-24 | 60 | 0d |  |  | Betonář [2500%]; Stavební dělník [500%] | 208.1h | 508,989.49 |
| 62 | 2.1.1.5.4.4 | Zdivo nosné - odbednění - 3NP | 1.17d? | 2015-05-05 | 2015-05-07 | 61FS+7d | 0d |  |  | Tesař [1000%]; Stavební dělník [2800%] | 356.66h | 199,941.33 |
| 63 | 2.1.1.5.4.5 | Prefabrikovaná výtahová šachta - 3NP | 1.2d? | 2015-04-28 | 2015-04-30 | 55, 50 | 69.01d | 29.73d |  | PREFA PRAHA a.s. [200%] | 19.15h | 124,946.77 |
| 64 | 2.1.1.5.4.6 | Stropy - zřízení podpěr - 3NP | 0.54d? | 2015-05-07 | 2015-05-07 | 62 | 0d |  |  | Tesař [1000%]; Stavební dělník [2800%] | 162.71h | 142,803.15 |
| 65 | 2.1.1.5.4.7 | Stropy - bednění - 3NP | 1.56d? | 2015-05-07 | 2015-05-11 | 64 | 0d |  |  | Tesař [1000%]; Stavební dělník [2000%] | 375.55h | 272,669.32 |
| 66 | 2.1.1.5.4.8 | Stropy - výztuž - 3NP | 2.24d? | 2015-05-11 | 2015-05-13 | 65 | 0d |  |  | Železář [1500%]; Stavební dělník [2000%] | 626.29h | 762,010.68 |
| 67 | 2.1.1.5.4.9 | Stropy - beton - 3NP | 0.72d? | 2015-05-13 | 2015-05-14 | 66 | 0d |  |  | Betonář [2500%]; Stavební dělník [2000%] | 260.69h | 630,781.84 |
| 68 | 2.1.1.5.4.10 | Stropy - odbednění - 3NP | 1.74d? | 2015-06-09 | 2015-06-10 | 67FS+14d | 39.28d | 0d | start no earlier than 2015-06-09 | Tesař [1000%]; Stavební dělník [400%] | 194.57h | 74,322.09 |
| 69 | 2.1.1.5.4.11 | Stropy - odstranění podpěr - 3NP | 1.33d? | 2015-06-29 | 2015-06-30 | 67FS+28d, 56 | 60.01d | 30.16d |  | Stavební dělník [800%] | 85.33h | 35,112 |
| 70 | 2.1.1.5.4.12 | Prefabrikové schodiště a balkóny - 3NP | 0.84d? | 2015-06-10 | 2015-06-11 | 68, 57 | 60.06d | 33.77d |  | PREFA PRAHA a.s. [200%] | 13.48h | 98,746.54 |
| 71 | 2.1.1.5.5 | **4NP** | 54.6d? | 2015-05-28 | 2015-08-12 |  | 0d |  |  |  | 4054.04h | 4,288,262.41 |
| 72 | 2.1.1.5.5.1 | Zdivo nosné - bednění - 4NP | 4.37d? | 2015-05-28 | 2015-06-03 | 67FS+10d | 0d |  |  | Tesař [1000%]; Stavební dělník [2000%] | 1048.2h | 725,340.17 |
| 73 | 2.1.1.5.5.2 | Zdivo nosné - výztuž - 4NP | 2.51d? | 2015-06-03 | 2015-06-08 | 72 | 0d |  |  | Železář [1500%]; Stavební dělník [2000%] | 703.31h | 712,599.03 |
| 74 | 2.1.1.5.5.3 | Zdivo nosné - beton - 4NP | 0.87d? | 2015-06-08 | 2015-06-08 | 73 | 0d |  |  | Betonář [2500%]; Stavební dělník [500%] | 208.1h | 508,989.49 |
| 75 | 2.1.1.5.5.4 | Zdivo nosné - odbednění - 4NP | 1.49d? | 2015-06-17 | 2015-06-19 | 74FS+7d | 0d |  |  | Tesař [1000%]; Stavební dělník [2000%] | 356.66h | 199,941.33 |
| 76 | 2.1.1.5.5.5 | Prefabrikovaná výtahová šachta - 4NP | 1.2d? | 2015-06-10 | 2015-06-11 | 68, 63 | 39.28d | 33.42d |  | PREFA PRAHA a.s. [200%] | 19.15h | 124,946.77 |
| 77 | 2.1.1.5.5.6 | Stropy - zřízení podpěr - 4NP | 1.02d? | 2015-06-19 | 2015-06-22 | 75 | 0d |  |  | Stavební dělník [2000%] | 162.71h | 142,803.15 |
| 78 | 2.1.1.5.5.7 | Stropy - bednění - 4NP | 4.69d? | 2015-06-22 | 2015-06-29 | 77 | 0d |  |  | Tesař [1000%] | 375.55h | 272,669.32 |
| 79 | 2.1.1.5.5.8 | Stropy - výztuž - 4NP | 2.24d? | 2015-06-29 | 2015-07-01 | 78 | 0d |  |  | Železář [1500%]; Stavební dělník [2000%] | 626.29h | 762,010.68 |
| 80 | 2.1.1.5.5.9 | Stropy - beton - 4NP | 1.09d? | 2015-07-01 | 2015-07-02 | 79 | 0d |  |  | Železář [1500%]; Stavební dělník [1500%] | 260.69h | 630,781.84 |
| 81 | 2.1.1.5.5.10 | Stropy - odbednění - 4NP | 1.35d? | 2015-07-28 | 2015-07-29 | 80FS+14d | 5.86d | 0d | start no earlier than 2015-07-28 | Tesař [1000%]; Stavební dělník [800%] | 194.57h | 74,322.09 |
| 82 | 2.1.1.5.5.11 | Stropy - odstranění podpěr - 4NP | 1.33d? | 2015-08-11 | 2015-08-12 | 80FS+28d, 69 | 29.85d |  |  | Stavební dělník [800%] | 85.33h | 35,112 |
| 83 | 2.1.1.5.5.12 | Prefabrikové schodiště a balkóny - 4NP | 0.84d? | 2015-07-29 | 2015-07-30 | 81, 70 | 26.29d |  |  | PREFA PRAHA a.s. [200%] | 13.48h | 98,746.54 |

| ID | WBS | Task | Duration | Start | Finish | Predecessors | Total slack | Free slack | Resources | Work | Cost |
| --- | --- | --- | --- | --- | --- | --- | --- | --- | --- | --- | --- |
| 84 | 2.1.1.5.6 | **5NP** | 49.72d? | 2015-07-16 | 2015-09-24 |  | 0d |  |  | 4040.55h | 4,189,515.87 |
| 85 | 2.1.1.5.6.1 | Zdivo nosné - bednění - 5NP | 4.37d? | 2015-07-16 | 2015-07-22 | 80FS+10d | 0d |  | Tesař [1000%]; Stavební dělník [2000%] | 1048.2h | 725,340.17 |
| 86 | 2.1.1.5.6.2 | Zdivo nosné - výztuž - 5NP | 2.51d? | 2015-07-22 | 2015-07-27 | 85 | 0d |  | Železář [1500%]; Stavební dělník [2000%] | 703.31h | 712,599.03 |
| 87 | 2.1.1.5.6.3 | Zdivo nosné - beton - 5NP | 0.87d? | 2015-07-27 | 2015-07-28 | 86 | 0d |  | Betonář [2500%]; Stavební dělník [500%] | 208.1h | 508,989.49 |
| 88 | 2.1.1.5.6.4 | Zdivo nosné - odbednění - 5NP | 1.17d? | 2015-08-06 | 2015-08-07 | 87FS+7d | 0d |  | Tesař [1000%]; Stavební dělník [2800%] | 356.65h | 199,941.33 |
| 89 | 2.1.1.5.6.5 | Prefabrikovaná výtahová šachta - 5NP | 1.2d? | 2015-07-29 | 2015-07-30 | 81, 76 | 5.86d |  | PREFA PRAHA a.s. [200%] | 19.15h | 124,946.77 |
| 90 | 2.1.1.5.6.6 | Stropy - zřízení podpěr - 5NP | 0.54d? | 2015-08-07 | 2015-08-07 | 88, 89 | 0d |  | Tesař [1000%]; Stavební dělník [2800%] | 162.71h | 142,803.15 |
| 91 | 2.1.1.5.6.7 | Stropy - bednění - 5NP | 1.68d? | 2015-08-07 | 2015-08-11 | 90 | 0d |  | Tesař [1000%]; Stavební dělník [1800%] | 375.55h | 272,669.32 |
| 92 | 2.1.1.5.6.8 | Stropy - výztuž - 5NP | 2.24d? | 2015-08-11 | 2015-08-13 | 91 | 0d |  | Železář [1500%]; Stavební dělník [2000%] | 626.29h | 762,010.68 |
| 93 | 2.1.1.5.6.9 | Stropy - beton - 5NP | 0.81d? | 2015-08-13 | 2015-08-14 | 92 | 0d |  | Betonář [2500%]; Stavební dělník [1500%] | 260.69h | 630,781.84 |
| 94 | 2.1.1.5.6.10 | Stropy - odbednění - 5NP | 0.81d? | 2015-09-03 | 2015-09-04 | 93FS+14d | 0d |  | Tesař [1000%]; Stavební dělník [2000%] | 194.57h | 74,322.09 |
| 95 | 2.1.1.5.6.11 | Stropy - odstranění podpěr - 5NP | 0.53d? | 2015-09-23 | 2015-09-24 | 93FS+28d, 82 | 0d |  | Stavební dělník [2000%] | 85.33h | 35,112 |
| 96 | 2.1.1.5.7 | Nosná kce + schody terasy 1NP | 0.31d? | 2015-09-04 | 2015-09-04 | 94, 17 | 4.87d | 0d | STANO PRAHA a.s. | 2.5h | 231,208.7 |
| 97 | 2.1.1.5.8 | Střechy | 13.58d | 2015-09-04 | 2015-09-24 | 94, 83 | 0d |  | IZOSTAV, s. r. o. [1000%] | 1086.68h | 2,998,455.65 |
| 98 | 2.1.1.5.9 | Terasy 1NP, 4NP - izolace + povrchová úprava | 8.4d | 2015-09-04 | 2015-09-17 | 94, 96, 83 | 4.87d |  | IZOSTAV, s. r. o. [900%] | 604.91h | 642,286.57 |
| 99 | 2.1.1.6 | Příčky | 11.86d? | 2015-09-10 | 2015-09-28 | 30, 95FF+2d, 5FF | 14.79d |  | Zedník [2000%]; Stavební dělník [1000%] | 2846.45h | 3,070,170.15 |
| 100 | 2.1.2 | **PSV** | 198.63d? | 2015-09-04 | 2016-06-09 |  | 0d |  |  | 31724.5h | 57,593,732.01 |
| 101 | 2.1.2.1 | **Venkovní práce** | 70.23d | 2015-09-04 | 2015-12-11 |  | 13.58d |  |  | 10736.9h | 25,446,013.72 |
| 102 | 2.1.2.1.1 | Lešení | 2.84d | 2015-09-04 | 2015-09-09 | 94 | 158.32d | 31.68d | NELOstaV,s.r.o. [1500%] | 340.67h | 2,669,120.9 |
| 103 | 2.1.2.1.2 | Okna a balkónové dveře | 16.93d | 2015-09-24 | 2015-10-16 | 97, 98 | 0d |  | NELAN, spol. s r.o. [1600%] | 2167.53h | 4,029,462.19 |
| 104 | 2.1.2.1.3 | Zábradlí kovová | 4d | 2015-10-16 | 2015-10-22 | 103 | 126.64d | 0d | STANO PRAHA a.s. | 482.32h | 3,508,496.95 |
| 105 | 2.1.2.1.4 | Fasáda | 29.76d | 2015-10-22 | 2015-12-03 | 102, 103, 97FF, 98FF, 104 | 126.64d | 0d | STANO PRAHA a.s. [2500%] | 5952.84h | 5,349,934.78 |
| 106 | 2.1.2.1.5 | Lešení - demontáž | 2.72d | 2015-12-03 | 2015-12-08 | 105 | 126.64d | 0d | NELOstaV,s.r.o. [1000%] | 217.57h | 70,939.91 |
| 107 | 2.1.2.1.6 | Vstupní dveře + zádveří | 3.23d | 2015-12-08 | 2015-12-11 | 106 | 126.64d | 0d | NELAN, spol. s r.o. [1500%] | 388h | 193,269.42 |

| ID | WBS | Task | Duration | Start | Finish | Predecessors | Total slack | Free slack | Constraint | Resources | Work | Cost |
| --- | --- | --- | --- | --- | --- | --- | --- | --- | --- | --- | --- | --- |
| 108 | 2.1.2.1.7 | **Vnitřní rozvody** | 32d | 2015-10-16 | 2015-12-01 | 103, 99 | 0d |  |  |  | 1188h | 9,624,789.57 |
| 109 | 2.1.2.1.7.1 | Vodovod - rozvody | 18d | 2015-10-16 | 2015-11-11 | 110FF | 14d |  |  | FA: JANPE s.r.o. | 144h | 1,090,960 |
| 110 | 2.1.2.1.7.2 | Instalační prefabrikáty | 6d | 2015-10-16 | 2015-10-26 |  | 26d | 12d |  | FA: JANPE s.r.o. | 48h | 315,000 |
| 111 | 2.1.2.1.7.3 | Vodovod - hydrant | 1.5d | 2015-10-16 | 2015-10-20 |  | 30.5d |  |  | FA: JANPE s.r.o. | 100h | 272,740 |
| 112 | 2.1.2.1.7.4 | Kanalizace vnitřní | 18d | 2015-10-16 | 2015-11-11 |  | 14d |  |  | FA: JANPE s.r.o. | 144h | 773,227.36 |
| 113 | 2.1.2.1.7.5 | Vytápění - rozvody + radiátory | 12d | 2015-10-16 | 2015-11-03 |  | 20d |  |  | FA: JANPE s.r.o. | 96h | 2,217,950 |
| 114 | 2.1.2.1.7.6 | Slaboproud - rozvody | 20d | 2015-10-16 | 2015-11-13 |  | 12d |  |  | ELEKTROMONTÁŽE s.r.o. | 160h | 733,280 |
| 115 | 2.1.2.1.7.7 | Vzduchotechnika - rozvody | 3d | 2015-10-16 | 2015-10-21 |  | 29d |  |  | SORKE,spol. s r.o. | 240h | 764,066.4 |
| 116 | 2.1.2.1.7.8 | Silnoproud - rozvody | 32d | 2015-10-16 | 2015-12-01 |  | 0d |  |  | ELEKTROMONTÁŽE s.r.o. | 256h | 3,457,565.81 |
| 117 | 2.1.2.2 | Podlahy hrubé | 13.45d | 2015-12-01 | 2015-12-21 | 108 | 0d |  |  | STANO PRAHA a.s. [2000%] | 2152.25h | 3,240,457.8 |
| 118 | 2.1.2.3 | Zařizovací předměty - vany | 0.6d | 2015-12-21 | 2015-12-22 | 117 | 0d |  |  | FA: JANPE s.r.o. [200%] | 9.53h | 680,090.48 |
| 119 | 2.1.2.4 | Obezdívky | 0.16d? | 2015-12-22 | 2015-12-22 | 118 | 0d |  |  | Zedník [2000%] | 26.06h | 17,352.26 |
| 120 | 2.1.2.5 | Omítky vnitřní | 48.12d? | 2015-12-22 | 2016-02-26 | 119 | 0d |  |  | Omítkář [1000%]; Stavební dělník [2000%] | 7699.97h | 4,412,066.99 |
| 121 | 2.1.2.6 | Pomocné lešení | 17.22d? | 2016-02-08 | 2016-03-02 | 119, 120SS, 122FF, 123FF | 70.87d |  |  | Stavební dělník [200%] | 275.46h | 108,191.49 |
| 122 | 2.1.2.7 | Zateplení podhledu 1PP | 2.91d | 2016-02-26 | 2016-03-02 | 120 | 26.9d | 0d |  | STANO PRAHA a.s. [800%] | 186.06h | 461,277.23 |
| 123 | 2.1.2.8 | SDK podhledy | 2.25d | 2016-02-26 | 2016-03-01 | 120 | 0d |  |  | STANO PRAHA a.s. [800%] | 144.23h | 110,159.17 |
| 124 | 2.1.2.9 | **Nášlapné vrstvy podlah** | 15.76d | 2016-03-01 | 2016-03-23 | 123 | 0d |  |  |  | 2102.78h | 6,025,371.46 |
| 125 | 2.1.2.9.1 | SDK předstěny | 4.67d | 2016-03-01 | 2016-03-08 | 120 | 0d |  |  | STANO PRAHA a.s. [1000%] | 373.38h | 317,518.94 |
| 126 | 2.1.2.9.2 | Dlažba | 11.09d | 2016-03-08 | 2016-03-23 | 127FF, 123, 125 | 0d |  |  | STANO PRAHA a.s. [1000%] | 887.59h | 1,292,442.8 |
| 127 | 2.1.2.9.3 | Vytápění - konvektory | 1d | 2016-03-01 | 2016-03-02 |  | 14.76d |  |  | FA: JANPE s.r.o. | 75h | 665,385 |
| 128 | 2.1.2.9.4 | Koberec | 8.79d | 2016-03-01 | 2016-03-14 |  | 62.73d |  |  | STANO PRAHA a.s. [800%] | 562.55h | 2,982,797.42 |
| 129 | 2.1.2.9.5 | Podlaha 1PP | 3.19d | 2016-03-02 | 2016-03-07 | 122 | 26.9d | 0d |  | STANO PRAHA a.s. [800%] | 204.26h | 767,227.3 |
| 130 | 2.1.2.10 | Obklady | 14.65d | 2016-03-23 | 2016-04-13 | 126 | 0d |  |  | STANO PRAHA a.s. [1200%] | 1406.78h | 1,609,628.65 |
| 131 | 2.1.2.11 | Plechové příčky | 2.05d | 2016-03-07 | 2016-03-09 | 129 | 26.9d | 0d |  | NELAN, spol. s r.o. [400%] | 65.62h | 26,094.6 |
| 132 | 2.1.2.12 | Vytápění - výměník | 2d | 2016-03-07 | 2016-03-09 | 129 | 26.95d |  |  | FA: JANPE s.r.o. | 175h | 1,552,565 |
| 133 | 2.1.2.13 | Zařizovací předměty - mimo vany | 2.38d | 2016-04-13 | 2016-04-15 | 130 | 0d |  |  | FA: JANPE s.r.o. [200%] | 38.1h | 2,720,361.9 |
| 134 | 2.1.2.14 | Malby | 11.13d | 2016-04-15 | 2016-05-02 | 133, 132, 131 | 0d |  |  | Malba [2000%] | 1781.5h | 1,062,489.58 |
| 135 | 2.1.2.15 | Nátěr ocelových příček a zárubní | 5.16d | 2016-03-09 | 2016-03-16 | 131 | 60.47d |  |  | NELAN, spol. s r.o. [600%] | 247.49h | 151,590.85 |
| 136 | 2.1.2.16 | Silnoproud - kompletace | 3.47d | 2016-05-02 | 2016-05-05 | 134, 137FF | 2.53d |  |  | ELEKTROMONTÁŽE s.r.o. [600%] | 166.38h | 864,391.45 |
| 137 | 2.1.2.17 | Výtah | 35d | 2016-02-26 | 2016-04-15 | 120 | 17.19d | 14.65d |  | DOMOVNÍ VÝTAHY s.r.o. | 196h | 2,700,000 |
| 138 | 2.1.2.18 | Slaboproud - kompletace | 2d | 2016-05-06 | 2016-05-10 | 134, 139FF, 140FF | 0d |  |  | ELEKTROMONTÁŽE s.r.o. | 100h | 183,320 |
| 139 | 2.1.2.19 | Garážová vrata | 0.9d | 2016-05-02 | 2016-05-03 | 134 | 5.1d |  |  | NELAN, spol. s r.o. [200%] | 14.45h | 43,083.29 |
| 140 | 2.1.2.20 | Vzduchotechnika - kompletace | 6d | 2016-05-02 | 2016-05-10 | 134 | 0d |  |  | SORKE,spol. s r.o. | 48h | 191,016.6 |
| 141 | 2.1.2.21 | Dveře | 13.59d | 2016-05-10 | 2016-05-30 | 136, 138 | 0d |  |  | NELAN, spol. s r.o. [1800%] | 1956.91h | 5,185,388.77 |
| 142 | 2.1.2.22 | Schránka | 1d? | 2016-05-02 | 2016-05-03 | 134 | 18.59d |  |  | Stavební dělník [34.1%] | 2.73h | 138,310.23 |
| 143 | 2.1.2.23 | Vyčištění budovy | 8d? | 2016-05-30 | 2016-06-09 | 141, 142 | 0d |  |  | Stavební dělník [3000%] | 1920h | 311,116.12 |
| 144 | 2.1.2.24 | Okapový chodníček | 0.12d? | 2015-12-08 | 2015-12-08 | 106 | 129.88d | 3.24d |  | Zedník [2000%]; Stavební dělník [3000%] | 39.13h | 54,603.25 |
| 145 | 2.1.2.25 | Oplocení | 0.72d? | 2015-12-08 | 2015-12-08 |  | 129.76d | 3.12d | start no earlier than 2015-12-08 | Stavební dělník [3000%] | 173.51h | 141,789.84 |
| 146 | 2.1.2.26 | Přístupový chodník - zámková dlažba | 0.13d? | 2015-12-11 | 2015-12-11 | 106, 107 | 126.64d | 0d |  | Zedník [2000%] | 20.19h | 14,279.73 |
| 147 | 2.1.2.27 | Vegetační střecha - vjezd do garáží | 1.64d | 2015-12-08 | 2015-12-10 | 106 | 128.36d | 1.72d |  | IZOSTAV, s. r. o. [300%] | 39.39h | 142,721.55 |
| 148 | 2.2 | SO 02 - Kanalizační přípojka | 1.63d | 2014-12-15 | 2014-12-17 | 15FF | 182.88d | 3.58d |  | FA: JANPE s.r.o. [600%] | 78.22h | 47,674.5 |
| 149 | 2.3 | SO 03 - Vodovodní přípojka | 0.59d | 2014-12-16 | 2014-12-17 | 15FF | 182.88d | 3.58d |  | FA: JANPE s.r.o. [600%] | 28.55h | 17,882.5 |
| 150 | 2.4 | SO 04 - Přípojky NN | 0.44d | 2014-12-17 | 2014-12-17 | 15FF | 182.88d | 3.58d |  | FA: JANPE s.r.o. [600%] | 21.35h | 13,010.7 |
| 151 | 2.5 | SO 05 - Horkovodní přípojka | 2.17d | 2014-12-15 | 2014-12-17 | 15FF | 182.88d | 3.58d |  | FA: JANPE s.r.o. [800%] | 138.79h | 84,593 |
| 152 | 2.6 | SO 06 - Přeložka kanalizace | 5.74d | 2014-08-28 | 2014-09-04 | 155 | 0d |  |  | FA: JANPE s.r.o. [2000%] | 917.87h | 559,452.4 |
| 153 | 2.7 | SO 07 - Dešťová kanalizace | 2.94d | 2014-10-06 | 2014-10-08 | 6 | 232.48d | 0d |  | FA: JANPE s.r.o. [2000%] | 469.73h | 1,404,611.52 |
| 154 | 2.8 | SO 08 - Příjezdová komunikace | 1.8d | 2014-10-08 | 2014-10-10 | 153 | 430.67d | 0d |  | INPROS PRAHA, a.s. [600%] | 86.2h | 49,936.6 |
| 155 | 2.9 | SO 09 - HTÚ | 4.23d | 2014-08-22 | 2014-08-28 |  | 0d |  |  | Milan Červený s.r.o. [1500%] | 507.65h | 294,074.6 |
| 156 | 2.10 | SO 11 - Stání pro kontejnery na KO | 1.02d? | 2014-10-10 | 2014-10-13 | 154 | 430.67d | 304.03d |  | Zedník [2000%]; Stavební dělník [500%] | 203.89h | 118,110.3 |
| 157 | 2.11 | SO 10 - Sadové a terénní úpravy | 1.63d? | 2015-12-11 | 2015-12-15 | 106, 154, 156, 145, 146, 144, 147 | 126.64d |  |  | INPROS PRAHA, a.s. [200%] | 26.04h | 16,263.3 |
